# REGNET02

Schedule from MS Project, 2001-01-01 to 2003-01-01.
Cultural Heritage & E-Commerce
AIT

## Calendars

- Standard: Mon-Fri 08:00-12:00, 13:00-17:00; Sat-Sun off.

## Schedule

| ID | WBS | Task | Type | Duration | Start | Finish | Predecessors | Baseline start | Baseline finish | Baseline duration | Total slack | Free slack | Constraint |
| --- | --- | --- | --- | --- | --- | --- | --- | --- | --- | --- | --- | --- | --- |
| 1 | 1 | **WP-1 Analysis of the State of the Art and Development of Concepts** |  | 130d | 2001-01-01 | 2001-06-29 |  | 2001-01-01 | 2001-06-29 | 130d | 392d |  |  |
| 2 | 1.1 | T1.1 Definition of content to be provided |  | 65d | 2001-01-01 | 2001-03-30 |  | 2001-01-01 | 2001-06-29 | 130d | 392d | 0d | finish no earlier than 2001-03-30 |
| 3 | 1.2 | T1.2 Development of a documentation and digitization plan for content reation and management |  | 65d | 2001-04-02 | 2001-06-29 | 2 | 2001-01-01 | 2001-01-01 | 1d | 392d |  |  |
| 4 | 1.3 | T1.3 Identification of standards to be used |  | 43d | 2001-01-01 | 2001-02-28 |  | 2001-01-01 | 2001-01-01 | 1d | 392d | 0d | finish no earlier than 2001-02-28 |
| 5 | 1.4 | T1.4 Development of the System Specifications |  | 107d | 2001-02-01 | 2001-06-29 |  | 2001-01-01 | 2001-01-01 | 1d | 392d |  | finish no earlier than 2001-06-29 |
| 6 | 1.5 | T1.5 Setup of the Legal Framework and Partnership Model |  | 65d | 2001-04-02 | 2001-06-29 | 7 | 2001-01-01 | 2001-01-01 | 1d | 392d |  | start no earlier than 2001-04-01 |
| 7 | 1.6 | T1.6 Definition of supported Business Functions |  | 65d | 2001-01-01 | 2001-03-30 |  | 2001-01-01 | 2001-01-01 | 1d | 457d |  | finish no earlier than 2001-03-30 |
| 8 | 1.7 | T1.7 Identification of Market (Segments) and User Groups |  | 130d | 2001-01-01 | 2001-06-29 |  | 2001-01-01 | 2001-01-01 | 1d | 392d |  | start no earlier than 2001-01-01 |
| 9 | 2 | M1-Milestone 1 | milestone | 1d | 2001-07-02 | 2001-07-02 | 3, 5, 6, 8 | 2001-07-02 | 2001-07-02 | 1d | 392d |  | start no earlier than 2001-07-02 |
| 10 | 3 | **WP-2 Implementation of the System and Preparation of Services and Product Generation** |  | 131d | 2001-07-02 | 2001-12-31 |  | 2001-07-02 | 2001-12-31 | 131d | 261d |  |  |
| 11 | 3.1 | T2.1 Preparation of content and products |  | 130d | 2001-07-02 | 2001-12-28 |  | 2001-07-02 | 2001-12-28 | 130d | 262d | 65d | finish no earlier than 2001-12-28 |
| 12 | 3.2 | T2.2 System Implementation (1. Version) |  | 130d | 2001-07-02 | 2001-12-28 |  | 2001-07-02 | 2001-12-28 | 130d | 262d | 65d | finish no earlier than 2001-12-28 |
| 13 | 3.3 | T2.3 Setup of the legal framework |  | 131d | 2001-07-02 | 2001-12-31 |  | 2001-07-02 | 2001-12-31 | 131d | 261d | 0d | start no earlier than 2001-07-02 |
| 14 | 3.4 | T2.4 Business process (re-) engineering |  | 131d | 2001-07-02 | 2001-12-31 |  | 2001-07-02 | 2001-12-31 | 131d | 261d | 0d | start no earlier than 2001-07-02 |
| 15 | 3.5 | T2.5 Market preparation |  | 131d | 2001-07-02 | 2001-12-31 |  | 2001-07-02 | 2001-12-31 | 131d | 261d | 0d | start no earlier than 2001-07-02 |
| 16 | 4 | M2-Milestone 2 | milestone | 1d | 2002-01-01 | 2002-01-01 | 13, 14, 15, 11, 12 | 2002-01-01 | 2002-01-01 | 1d | 261d |  | start no earlier than 2002-01-01 |
| 17 | 5 | **WP-3 Validation and Preparation** |  | 64d | 2002-01-01 | 2002-03-29 |  | 2002-01-01 | 2002-03-29 | 64d | 197d |  |  |
| 18 | 5.1 | T3.1 Validation of the REGNET-Demonstrator |  | 64d | 2002-01-01 | 2002-03-29 |  | 2002-01-01 | 2002-03-29 | 64d | 197d |  | start no earlier than 2002-01-01 |
| 19 | 5.2 | T3.2 Preparation of the Demonstration Phase |  | 64d | 2002-01-01 | 2002-03-29 |  | 2002-01-01 | 2002-03-29 | 64d | 197d |  | start no earlier than 2002-01-01 |
| 20 | 5.3 | T3.3 Implementation of the version 2 of the REGNET system |  | 63d | 2002-01-02 | 2002-03-29 |  | 2002-01-02 | 2002-03-29 | 63d | 198d |  | start no earlier than 2002-01-02 |
| 21 | 6 | M3-Milestone 3 | milestone | 1d | 2002-04-01 | 2002-04-01 | 18, 19, 20 | 2002-04-01 | 2002-04-01 | 1d | 197d |  | start no earlier than 2002-04-01 |
| 22 | 7 | **WP-4 Demonstration, Assessment and Evaluation** |  | 175d | 2002-04-01 | 2002-11-29 |  | 2002-04-01 | 2002-11-29 | 175d | 22d |  |  |
| 23 | 7.1 | T4.1 Execution of the demonstration phase (trial service) |  | 131d | 2002-04-01 | 2002-09-30 |  | 2002-04-01 | 2002-09-30 | 131d | 22d | 0d | start no earlier than 2002-04-01 |
| 24 | 7.2 | T4.2 Refinement of system and services where appropriate and necessary |  | 131d | 2002-04-01 | 2002-09-30 |  | 2002-04-01 | 2002-09-30 | 131d | 66d | 44d | start no earlier than 2002-04-01 |
| 25 | 7.3 | T4.3 Analysis of the trial service, assessment and evaluation of the system |  | 44d | 2002-10-01 | 2002-11-29 | 23 | 2002-10-01 | 2002-11-29 | 44d | 22d | 0d | start no earlier than 2002-10-01 |
| 26 | 8 | M4-Milestone 4 | milestone | 1d | 2002-12-02 | 2002-12-02 | 25, 24 | 2002-12-02 | 2002-12-02 | 1d | 22d |  | start no earlier than 2002-12-02 |

| ID | WBS | Task | Type | Duration | Start | Finish | Predecessors | Baseline start | Baseline finish | Baseline duration | Total slack | Constraint |
| --- | --- | --- | --- | --- | --- | --- | --- | --- | --- | --- | --- | --- |
| 27 | 9 | **WP-5 Development of an exploitation plan** |  | 522d | 2001-01-01 | 2002-12-31 |  | 2001-01-01 | 2002-12-31 | 522d | 0d |  |
| 28 | 9.1 | T5.1 Development of a Technology implementation plan (Draft) |  | 261d | 2001-01-01 | 2001-12-31 |  | 2001-01-01 | 2001-12-31 | 261d | 0d | start no earlier than 2001-01-01 |
| 29 | 9.1 | T5.2 Development of a Technology implementation plan (final) |  | 261d | 2002-01-01 | 2002-12-31 | 28 | 2002-01-01 | 2002-12-31 | 261d | 0d | start no earlier than 2002-01-01 |
| 30 | 10 | **WP-6 Dissemination and Use plan** |  | 522d | 2001-01-01 | 2002-12-31 |  | 2001-01-01 | 2002-12-31 | 522d | 0d |  |
| 31 | 10.1 | T6.1 Information Dissemination |  | 522d | 2001-01-01 | 2002-12-31 |  | 2001-01-01 | 2002-12-31 | 522d | 0d | start no earlier than 2001-01-01 |
| 32 | 11 | **WP-7 Project Managament** |  | 522d | 2001-01-01 | 2002-12-31 |  | 2001-01-01 | 2002-12-31 | 522d | 0d |  |
| 33 | 11.1 | T7.1 Project Management |  | 522d | 2001-01-01 | 2002-12-31 |  | 2001-01-01 | 2002-12-31 | 522d | 0d | start no earlier than 2001-01-01 |
| 34 | 11.2 | T7.2 Quality Assurance |  | 522d | 2001-01-01 | 2002-12-31 |  | 2001-01-01 | 2002-12-31 | 522d | 0d | start no earlier than 2001-01-01 |
| 35 | 12 | M5-Milestone 5 | milestone | 1d | 2003-01-01 | 2003-01-01 | 29, 31, 33, 34 | 2003-01-01 | 2003-01-01 | 1d | 0d | start no earlier than 2002-12-31 |
